# MAPS Inner Barrel

Schedule from MS Project, 2017-10-02 to 2023-07-28, costs in $.
LANL

## Calendars

- Standard: Mon-Fri 08:00-12:00, 13:00-17:00; Sat-Sun off. Exceptions (off unless hours are given): 2017-10-09, 2017-11-10, 2017-11-23 to 2017-11-24, 2017-12-25 to 2017-12-29.

## Resources

| Resource | Rate | Cost per use |
| --- | --- | --- |
| Mech Liason Eng | 130 |  |
| Elec Liason Eng | 130 |  |
| Project Manager | 130 |  |
| Physicist |  |  |
| Elec tech | 97 |  |
| Mech Tech | 97 |  |
| Electronics Engineer | 130 |  |
| Mechanical Engineer | 130 |  |
| M&S |  | 1 |
| Electrical Engineer UTAustin | 160 |  |
| LDRD Physicist | 230 |  |
| LDRD PostDoc | 90 |  |
| LDRD Electronics Engineer | 230 |  |
| LDRD Mechnical Engineer | 230 |  |
| LDRD Mechnical Tech | 150 |  |
| LDRD Electronics Tech | 150 |  |
| PROF4_institution_LANL | 305.48 |  |
| SCI3_Institution_LANL |  |  |
| TECH4_Institution_LANL | 192.07 |  |
| PROF4_Institution_MIT | 163 |  |
| SCI3_Institution_MIT |  |  |
| TECH4_Institution_MIT | 95.5 |  |
| MECHTECH4_Institution_LBNL | 132 |  |
| STAFFPHYS_Institution_LBNL |  |  |
| ELENG3_Institution_LBNL | 181 |  |
| MECHENG3_Institution_LBNL | 161 |  |
| ELTECH4_Institution_LBNL | 118 |  |
| POSTD_Institution_LBNL |  |  |
| MACH4_Institution_LBNL | 154 |  |
| CMMTECH4_Institution_LBNL | 134 |  |
| MECHENG4_Institution_LBNL | 237 |  |
| GRSTUD_Institution_LBNL |  |  |
| MGR_Institution_LANL | 305.48 |  |
| ElectTech_Institution_UTAustin | 90 |  |

## Schedule

| ID | WBS | Task | Type | Duration | Start | Finish | Predecessors | Baseline start | Baseline finish | Baseline duration | Total slack | Free slack | Constraint | Resources | Work | Cost | Activity | Institution | Project Total Cost | Material contingency | Labor Contingency | Total Contingency | Text1 |
| --- | --- | --- | --- | --- | --- | --- | --- | --- | --- | --- | --- | --- | --- | --- | --- | --- | --- | --- | --- | --- | --- | --- | --- |
| 1 | 1 | **MVTX Inner Barrel** |  | 1130d | 2019-04-01 | 2023-07-28 |  |  |  |  |  |  | start no earlier than 2005-10-21 |  | 26095.5h | 3,699,123.8 |  |  |  |  |  |  |  |
| 2 | 1.1 | **ALICE ITS Key Tasks** |  | 380d | 2019-04-01 | 2020-09-11 |  | 2016-11-28 | 2018-07-17 | 413d | 557d |  |  |  |  |  |  |  |  |  |  |  |  |
| 3 | 1.1.1 | ALICE MAPS Production |  | 240d | 2019-04-01 | 2020-02-28 |  | 2016-11-28 | 2017-11-06 | 240d | 890d |  | start no earlier than 2016-11-28 |  |  |  |  |  |  |  |  |  |  |
| 4 | 1.1.2 | ALICE ITS IB FPC Production |  | 200d | 2019-04-01 | 2020-01-03 |  | 2017-02-23 | 2017-09-01 | 135d | 850d | 0d | start no earlier than 2017-06-01 |  |  |  |  |  |  |  |  |  |  |
| 5 | 1.1.3 | ALICE ITS IB Stave frame Production |  | 240d | 2019-05-27 | 2020-04-24 | 4SS+2mo | 2017-04-20 | 2018-04-06 | 240d | 850d | 0d | finish no earlier than 2018-01-02 |  |  |  |  |  |  |  |  |  |  |
| 6 | 1.1.4 | ALICE ITS IB Stave Assembly |  | 300d | 2019-07-22 | 2020-09-11 | 5SS+2mo | 2017-06-16 | 2018-09-01 | 306d | 750d |  | start no earlier than 2017-06-19 |  |  |  | ITS construction |  |  |  |  |  |  |
| 7 | 1.1.5 | **MVTX stave production at CERN** |  | 260d | 2019-05-01 | 2020-04-28 |  |  |  |  | 535d |  |  |  |  |  |  | CERN | CERN |  |  |  |  |
| 8 | 1.1.5.1 | Stave production batch #1 |  | 13w | 2019-05-01 | 2019-07-30 |  |  |  |  | 535d | 0d | start no earlier than 2019-05-01 |  |  |  |  |  | $0 |  |  |  |  |
| 9 | 1.1.5.2 | Stave production batch #2 |  | 13w | 2019-07-31 | 2019-10-29 | 8 |  |  |  | 828d | 0d |  |  |  |  |  |  | CERN |  |  |  |  |
| 10 | 1.1.5.3 | Stave production batch #3 |  | 13w | 2019-10-30 | 2020-01-28 | 9 |  |  |  | 828d | 0d |  |  |  |  |  |  | CERN |  |  |  |  |
| 11 | 1.1.5.4 | Stave production batch #4 |  | 13w | 2020-01-29 | 2020-04-28 | 10 |  |  |  | 828d | 0d |  |  |  |  |  |  | CERN |  |  |  |  |
| 12 | 1.1.6 | ALICE ITS Electronics Pre-Production |  | 100d | 2019-04-01 | 2019-08-16 |  | 2017-03-13 | 2017-08-01 | 100d | 790d | 0d | start no earlier than 2018-01-01 |  |  |  | ITS Electronics Pre-Production |  |  |  |  |  |  |
| 13 | 1.1.7 | ALICE ITS Electronics Production |  | 240d | 2019-08-19 | 2020-07-17 | 12 | 2017-08-02 | 2018-07-17 | 240d | 790d |  | start no earlier than 2018-02-01 |  |  |  | ITS Electronics Production |  |  |  |  |  |  |
| 14 | 1.2 | **sPHENIX Milestones** |  | 849d | 2017-10-02 | 2021-01-13 |  | 2016-11-01 | 2021-06-01 | 1181d |  |  |  |  |  |  |  |  |  |  |  |  |  |
| 15 | 1.2.1 | sPHENIX CD-1 Review | milestone | 0d | 2018-05-08 | 2018-05-08 |  | 2016-11-01 | 2016-11-01 | 0d | 1364d |  | start no earlier than 2018-05-08 |  |  |  |  |  |  |  |  |  |  |
| 16 | 1.2.2 | sPHENIX Construction starts PD2/3 | milestone | 0d | 2019-05-20 | 2019-05-20 |  | 2017-11-01 | 2017-11-01 | 0d | 1090d | 0d | start no earlier than 2019-05-20 |  |  |  |  |  |  |  |  |  |  |
| 17 | 1.2.3 | sPHENIX Installation Starts | milestone | 0d | 2021-04-01 | 2021-04-01 |  | 2021-04-01 | 2021-04-01 | 0d | 607d |  | start no earlier than 2021-04-01 |  |  |  |  |  |  |  |  |  |  |
| 18 | 1.2.4 | INTT Ready for Installation | milestone | 0d | 2022-04-01 | 2022-04-01 |  | 2022-04-01 | 2022-04-01 | 0d | -316d | 0d | start no earlier than 2022-04-01 |  |  |  |  |  |  |  |  |  |  |
| 19 | 1.2.5 | MVTX Ready for Installation | milestone | 0d | 2022-04-01 | 2022-04-01 | 18 |  |  |  | -316d | 0d |  |  |  |  |  |  |  |  |  |  |  |
| 20 | 1.2.6 | sPHENIX Installed and Ready for Beam | milestone | 0d | 2022-07-01 | 2022-07-01 | 19 | 2022-07-01 | 2022-07-01 | 0d | 151d | 0d | start no earlier than 2022-07-01 |  |  |  | ready for beam (6/2021) |  |  |  |  |  |  |
| 21 | 1.3 | **MVTX Project** |  | 1000d | 2019-04-01 | 2023-01-27 |  |  |  |  | 0d |  |  |  | 26095.5h | 3,699,123.8 |  |  |  |  |  |  |  |
| 22 | 1.3.1 | **MVTX Project Management** |  | 904d | 2019-04-01 | 2022-09-15 |  |  |  |  |  |  |  |  | 1548h | 543,049.76 | sPHENIX MAPS Project | LANL |  |  |  |  |  |
| 23 | 1.3.1.1 | Milestone Start MVTX | milestone | 0d | 2019-04-01 | 2019-04-01 |  |  |  |  | 130d | 0d | start no earlier than 2019-04-01 |  |  |  |  |  |  |  |  |  |  |
| 24 | 1.3.1.2 | lead Coordinator |  | 774d | 2019-04-01 | 2022-03-17 | 23 |  |  |  | 130d |  |  |  |  |  |  |  |  | .2 | .2 | .2 |  |
| 25 | 1.3.1.3 | Project Manager |  | 774d | 2019-04-01 | 2022-03-17 | 23 |  |  |  | 356d |  | finish no earlier than 2020-12-17 | MGR_Institution_LANL [20%] | 1238.4h | 394,478.21 |  |  |  | .2 | .2 | .2 |  |
| 26 | 1.3.1.4 | Mechanical Integration Engineer |  | 774d | 2019-04-01 | 2022-03-17 | 23 |  |  |  | 356d |  | finish no earlier than 2020-12-17 | PROF4_institution_LANL [5%] | 309.6h | 98,571.55 |  |  |  | .2 | .2 | .2 | DOE |
| 27 | 1.3.1.5 | Electronics Integration Engineer(sPHENIX) |  | 774d | 2019-04-01 | 2022-03-17 | 23 |  |  |  | 356d |  | finish no earlier than 2020-12-17 |  |  |  |  |  |  | .2 | .2 | .2 | DOE |
| 28 | 1.3.1.6 | Travel | manual | 774d | 2019-04-01 | 2022-03-17 | 23 |  |  |  |  |  | start no earlier than 2019-04-01 |  |  | 50,000 |  |  |  |  |  |  |  |

Notes:
- 7: ·4 staves / week maximum production rate at CERN. / ·21 staves per batch for shipment: give 40 days to produce a batch.
- 16: critical and lond lead time items can be purchased at CD3a
- 18: constructino fund available at CD-3b
- 20: commissioning 4/1-6/1, 2021; / ready for beam 6/1/2021
- 25: L3 project manager is on project

| ID | WBS | Task | Duration | Start | Finish | Predecessors | Total slack | Free slack | Constraint | Resources | Work | Cost | Institution | Material contingency | Labor Contingency | Total Contingency |
| --- | --- | --- | --- | --- | --- | --- | --- | --- | --- | --- | --- | --- | --- | --- | --- | --- |
| 29 | 1.3.2 | **Electronics** | 332d | 2019-04-01 | 2020-07-07 |  |  |  |  |  | 1421.04h | 400,881.1 | LANL |  |  |  |
| 30 | 1.3.2.1 | **Stave Extension Cable** | 182d | 2019-04-01 | 2019-12-10 |  | 150d |  |  |  | 160h |  | LANL |  |  |  |
| 31 | 1.3.2.1.1 | design | 4mo | 2019-04-01 | 2019-07-19 |  | 150d | 0d | start no earlier than 2018-08-01 |  |  |  |  | .35 | .35 | .35 |
| 32 | 1.3.2.1.2 | prototype | 2mo | 2019-07-22 | 2019-09-13 | 31 | 150d | 0d |  |  |  |  |  | .35 | .35 | .35 |
| 33 | 1.3.2.1.3 | review | 2d | 2019-09-16 | 2019-09-17 | 32 | 150d | 0d |  |  |  |  |  | .35 | .35 | .35 |
| 34 | 1.3.2.1.4 | procure | 2mo | 2019-09-18 | 2019-11-12 | 33 | 150d | 0d |  |  |  |  |  | .30 | .30 | .30 |
| 35 | 1.3.2.1.5 | test | 20d | 2019-11-13 | 2019-12-10 | 34 | 150d |  |  | SCI3_Institution_LANL | 160h |  |  | .35 | .35 | .35 |
| 36 | 1.3.2.2 | **RU** | 130d | 2019-04-01 | 2019-09-27 |  | 202d |  |  |  | 335.6h | 87,698.94 |  |  |  |  |
| 37 | 1.3.2.2.1 | Cold Plate | 4w | 2019-04-01 | 2019-04-26 | 23 | 202d | 0d |  | ElectTech_Institution_UTAustin [38%] | 60.8h | 17,576 |  | .35 | .35 | .35 |
| 38 | 1.3.2.2.2 | Transition board for RU | 2w | 2019-04-29 | 2019-05-10 | 37 | 202d | 0d |  | ElectTech_Institution_UTAustin [10%] | 8h | 9,436 |  | .2 | .2 | .2 |
| 39 | 1.3.2.2.3 | Power Mezzanine for RU | 2w | 2019-05-13 | 2019-05-24 | 38 | 202d | 0d |  | ElectTech_Institution_UTAustin [10%] | 8h | 5,405 |  | .2 | .2 | .2 |
| 40 | 1.3.2.2.4 | Test/QA RU | 1.25mo | 2019-05-27 | 2019-06-28 | 39 | 202d | 0d |  | SCI3_Institution_LANL [50%]; ElectTech_Institution_UTAustin [75%] | 250h | 21,000 |  | .35 | .35 | .35 |
| 41 | 1.3.2.2.5 | Procure 60 SamTec Cables | 60d | 2019-07-01 | 2019-09-20 | 40 | 202d | 0d | finish no earlier than 2018-10-26 | TECH4_Institution_LANL [1%] | 4.8h | 30,921.94 | LANL | .35 | .35 | .35 |
| 42 | 1.3.2.2.6 | Ship to UT Austin from CERN | 1w | 2019-09-23 | 2019-09-27 | 41 | 202d | 0d |  |  |  | 2,000 |  | .35 | .35 | .35 |
| 43 | 1.3.2.2.7 | Ship to BNL | 5d | 2019-04-01 | 2019-04-05 |  | 327d |  |  | ElectTech_Institution_UTAustin [10%] | 4h | 1,360 |  | .35 | .35 | .35 |
| 44 | 1.3.2.3 | **FELIX** | 70.33d | 2020-04-01 | 2020-07-08 |  | -0.33d | 0d |  |  | 193.6h | 96,675.2 |  |  |  |  |
| 45 | 1.3.2.3.1 | Produce first production unit | 4w | 2020-04-01 | 2020-04-28 |  | -0.33d | 0d | start no earlier than 2020-04-01 | TECH4_Institution_LANL [10%] | 16h | 11,152 |  | .2 | .2 | .2 |
| 46 | 1.3.2.3.2 | Procure Optical fiber | 2w | 2020-04-01 | 2020-04-14 | 45SS | -0.33d | 0d |  | TECH4_Institution_LANL [2%] | 1.6h | 365.2 |  | .2 | .2 | .2 |
| 47 | 1.3.2.3.3 | Test/QA | 2w | 2020-04-15 | 2020-04-28 | 46 | -0.33d | 0d |  | SCI3_Institution_LANL [50%] | 40h |  |  | .2 | .2 | .2 |
| 48 | 1.3.2.3.4 | Procure 7 Remaining Units | 8w | 2020-04-29 | 2020-06-23 | 40, 47 | -0.33d | 0d | finish no earlier than 2018-12-20 | TECH4_Institution_LANL [2%] | 6.4h | 57,260.8 | LANL | .2 | .2 | .2 |
| 49 | 1.3.2.3.5 | Procure 57 optical fibers | 2w | 2020-04-29 | 2020-05-12 | 47 | 29.67d |  |  | TECH4_Institution_LANL [2%] | 1.6h | 3,165.2 |  | .2 | .2 | .2 |
| 50 | 1.3.2.3.6 | test/QA | 5.33d | 2020-06-24 | 2020-07-01 | 48, 49 | -0.33d | 0d |  | SCI3_Institution_LANL; TECH4_Institution_LANL; Electrical Engineer UTAustin | 128h | 22,732 |  | .2 | .2 | .2 |
| 51 | 1.3.2.3.7 | Ship to BNL | 1w | 2020-07-01 | 2020-07-08 | 50 | -0.33d | 0d |  |  |  | 2,000 |  | .35 | .35 | .35 |
| 52 | 1.3.2.4 | **MAPS Power System** | 200.77d | 2019-04-01 | 2020-01-06 |  | 131.23d |  |  |  | 731.84h | 216,506.96 | LBNL |  |  |  |
| 53 | 1.3.2.4.1 | **Power Boards** | 75d | 2019-04-01 | 2019-07-12 |  | 257d |  |  |  | 432.4h | 128,692.44 | LBNL |  |  |  |
| 54 | 1.3.2.4.1.1 | Fabricate Break Out Boards | 20d | 2019-04-01 | 2019-04-26 | 23 | 257d | 0d |  |  |  | 6,600 |  | .2 | .2 | .2 |
| 55 | 1.3.2.4.1.2 | Fabricate PB to Stave Cables | 60h | 2019-04-29 | 2019-05-08 | 54 | 304.5d |  |  | ELTECH4_Institution_LBNL | 60h | 15,080 |  | .2 | .2 | .2 |
| 56 | 1.3.2.4.1.3 | Fabricate cold (cooling) plates | 2w | 2019-04-29 | 2019-05-10 | 54 | 302d |  |  | MECHTECH4_Institution_LBNL [20%] | 16h | 5,532 |  | .2 | .2 | .2 |
| 57 | 1.3.2.4.1.4 | Fabricate Production PB | 40d | 2019-04-29 | 2019-06-21 | 54 | 257d | 0d | finish no earlier than 2018-06-01 | ELENG3_Institution_LBNL [13%]; POSTD_Institution_LBNL [25%]; STAFFPHYS_Institution_LBNL [25%]; ELTECH4_Institution_LBNL [13%] | 86.4h | 68,620.44 |  | .2 | .2 | .2 |
| 58 | 1.3.2.4.1.5 | Assemble power boards | 30h | 2019-06-24 | 2019-06-27 | 57 | 257d | 0d |  | ELTECH4_Institution_LBNL | 30h | 3,540 |  | .2 | .2 | .2 |
| 59 | 1.3.2.4.1.6 | Test PB | 90h | 2019-06-27 | 2019-07-12 | 58 | 257d |  |  | ELTECH4_Institution_LBNL | 90h | 10,620 |  | .2 | .2 | .2 |
| 60 | 1.3.2.4.1.7 | Power cable harness | 15d | 2019-04-29 | 2019-05-17 | 54 | 297d |  |  | ELTECH4_Institution_LBNL | 120h | 14,160 |  | .2 | .2 | .2 |
| 61 | 1.3.2.4.1.8 | Ship to BNL | 30h | 2019-04-01 | 2019-04-04 |  | 328.25d |  |  | ELTECH4_Institution_LBNL | 30h | 4,540 |  | .2 | .2 | .2 |

Notes:
- 45: Use ALICE design files

| ID | WBS | Task | Duration | Start | Finish | Predecessors | Total slack | Free slack | Constraint | Resources | Work | Cost | Material contingency | Labor Contingency | Total Contingency | Institution |
| --- | --- | --- | --- | --- | --- | --- | --- | --- | --- | --- | --- | --- | --- | --- | --- | --- |
| 62 | 1.3.2.4.2 | **Power Supplies** | 200.77d | 2019-04-01 | 2020-01-06 |  | 131.23d |  |  |  | 299.44h | 87,814.52 |  |  |  |  |
| 63 | 1.3.2.4.2.1 | CAEN A3484 48V PS | 200.77d | 2019-04-01 | 2020-01-06 | 23 | 131.23d |  | finish no earlier than 2016-10-03 | POSTD_Institution_LBNL [13%] | 208.8h | 8,607 | .2 | .2 | .2 |  |
| 64 | 1.3.2.4.2.2 | CAEN SY4527 Main Frame | 30d | 2019-04-01 | 2019-05-10 |  | 284.34d | 0d |  |  |  | 11,620 | .2 | .2 | .2 |  |
| 65 | 1.3.2.4.2.3 | CAEN A4532 Power Booster | 1w | 2019-05-13 | 2019-05-17 | 64 | 284.34d | 0d |  |  |  | 1,216 | .2 | .2 | .2 |  |
| 66 | 1.3.2.4.2.4 | CAEN A2518 power module(16) | 1.33d | 2019-05-20 | 2019-05-21 | 65 | 284.34d | 0d |  |  |  | 43,676 | .2 | .2 | .2 |  |
| 67 | 1.3.2.4.2.5 | Cabling | 1w | 2019-05-21 | 2019-05-28 | 66, 23 | 284.34d | 0d |  | ELTECH4_Institution_LBNL | 40h | 14,720 | .2 | .2 | .2 |  |
| 68 | 1.3.2.4.2.6 | test PB with PS | 1w | 2019-05-28 | 2019-06-04 | 67 | 284.34d | 0d |  | ELTECH4_Institution_LBNL | 40h | 4,720 | .2 | .2 | .2 |  |
| 69 | 1.3.2.4.2.7 | ship to BNL | 1.33d | 2019-06-04 | 2019-06-05 | 68 | 284.34d | 0d |  | ELTECH4_Institution_LBNL | 10.64h | 3,255.52 | .2 | .2 | .2 |  |
| 70 | 1.3.3 | **Mechanics and Detector Assembly** | 1000d | 2019-04-01 | 2023-01-27 |  | 130d |  |  |  | 16345.6h | 1,784,400.26 |  |  |  | LBNL |
| 71 | 1.3.3.1 | **Staves** | 289d | 2019-04-01 | 2020-05-07 |  | 622d |  |  |  | 4172.57h | 270,885.76 |  |  |  |  |
| 72 | 1.3.3.1.1 | **Production** | 267d | 2019-04-01 | 2020-04-07 |  | 863d |  |  |  | 2726.8h | 57,432.4 |  |  |  |  |
| 73 | 1.3.3.1.1.1 | Tests and QA at CERN | 160d | 2019-07-31 | 2020-03-10 | 8 | 863d | 0d |  | SCI3_Institution_LANL | 1280h |  | .35 | .35 | .35 | LANL |
| 74 | 1.3.3.1.1.2 | CERN Test System | 1d | 2019-04-01 | 2019-04-01 |  | 1129d |  | start no earlier than 2018-01-01 | ELENG3_Institution_LBNL [5%]; POSTD_Institution_LBNL [50%]; STAFFPHYS_Institution_LBNL [30%] | 6.8h | 7,432.4 | .35 | .35 | .35 | LANL |
| 75 | 1.3.3.1.1.3 | Travel and Per Diem at CERN | 1d | 2019-05-20 | 2019-05-20 | 16 | 1094d |  | start no earlier than 2016-10-03 |  |  | 50,000 | .35 | .35 | .35 | LANL |
| 76 | 1.3.3.1.1.4 | Tests and QA at CERN | 180d | 2019-07-31 | 2020-04-07 | 73SS | 863d |  |  | SCI3_Institution_LANL | 1440h |  | .35 | .35 | .35 | LANL |
| 77 | 1.3.3.1.2 | **Stave Assembly Tooling** | 109d | 2019-10-22 | 2020-03-20 |  | 875d |  |  |  | 264h | 69,352 |  |  |  | MIT |
| 78 | 1.3.3.1.2.1 | design | 2w | 2019-10-22 | 2019-11-04 | 126 | 974d |  |  | PROF4_Institution_MIT | 80h | 13,440 | .35 | .35 | .35 |  |
| 79 | 1.3.3.1.2.2 | final jig design | 20d | 2019-12-02 | 2019-12-27 | 103 | 875d | 0d |  | PROF4_Institution_MIT | 160h | 26,880 | .35 | .35 | .35 |  |
| 80 | 1.3.3.1.2.3 | procure Assembly Fixtures and tooling | 60d | 2019-12-30 | 2020-03-20 | 79 | 875d |  |  | PROF4_Institution_MIT [5%] | 24h | 29,032 | .35 | .35 | .35 |  |
| 81 | 1.3.3.1.3 | **Metrology** | 65d | 2019-10-22 | 2020-01-20 |  | 919d |  |  |  | 363.2h | 65,006.56 |  |  |  | MIT |
| 82 | 1.3.3.1.3.1 | Metrology design | 1mo | 2019-10-22 | 2019-11-18 | 126 | 919d | 0d |  | PROF4_Institution_MIT | 160h | 26,880 | .35 | .35 | .35 |  |
| 83 | 1.3.3.1.3.2 | Design jigs | 20d | 2019-11-19 | 2019-12-16 | 82 | 919d | 0d |  | PROF4_Institution_MIT | 160h | 26,880 | .35 | .35 | .35 |  |
| 84 | 1.3.3.1.3.3 | Procure jigs | 4w | 2019-12-17 | 2020-01-13 | 83 | 919d | 0d |  | TECH4_Institution_MIT [2%] | 3.2h | 5,314.56 | .35 | .35 | .35 |  |
| 85 | 1.3.3.1.3.4 | ship to LBNL | 1w | 2020-01-14 | 2020-01-20 | 84 | 919d |  |  | TECH4_Institution_MIT | 40h | 5,932 | .35 | .35 | .35 |  |

Notes:
- 74: From ITS: possible small modification and setup
- 75: 1 FTE lodging(100) and per diem(50) for 6 months; / $4.5K/month x6 = 27,000

| ID | WBS | Task | Type | Duration | Start | Finish | Predecessors | Total slack | Free slack | Constraint | Resources | Work | Cost | Institution | Material contingency | Labor Contingency | Total Contingency | Project Total Cost |
| --- | --- | --- | --- | --- | --- | --- | --- | --- | --- | --- | --- | --- | --- | --- | --- | --- | --- | --- |
| 86 | 1.3.3.1.4 | **Shipping and Storage Containers** |  | 196d | 2019-04-01 | 2019-12-30 |  | 934d |  |  |  | 594.57h | 55,094.8 | LBNL |  |  |  |  |
| 87 | 1.3.3.1.4.1 | Design&Fabricate Storage Cabinets for Staves |  | 39d | 2019-04-01 | 2019-05-23 | 23 | 1091d |  | start no earlier than 2017-11-01 | MECHTECH4_Institution_LBNL [13%]; STAFFPHYS_Institution_LBNL [25%]; POSTD_Institution_LBNL [50%] | 274.57h | 12,346.8 |  | .35 | .35 | .35 |  |
| 88 | 1.3.3.1.4.2 | Design&Fabricate Shipping and Storage Containers (Half-Barrels) |  | 50d | 2019-10-22 | 2019-12-30 | 23, 126 | 934d |  | start no earlier than 2017-11-01 | MECHTECH4_Institution_LBNL [10%]; STAFFPHYS_Institution_LBNL [25%]; POSTD_Institution_LBNL [33%] | 272h | 16,980 |  | .35 | .35 | .35 |  |
| 89 | 1.3.3.1.4.3 | Design shipping container for 21 staves |  | 1w | 2019-05-20 | 2019-05-24 | 16 | 1090d |  |  | MECHENG4_Institution_LBNL | 40h | 9,480 |  | .35 | .35 | .35 |  |
| 90 | 1.3.3.1.4.4 | procure stave shipping plate 84 |  | 1d | 2019-04-01 | 2019-04-01 |  | 1089d | 0d | start no earlier than 2018-01-01 | MECHENG3_Institution_LBNL | 8h | 11,288 |  | .3 | .3 | .3 |  |
| 91 | 1.3.3.1.4.5 | ship to CERN |  | 2mo | 2019-04-02 | 2019-05-27 | 90 | 1089d |  |  |  |  | 5,000 |  | .35 | .35 | .35 |  |
| 92 | 1.3.3.1.5 | **Shipping staves to LBNL** |  | 202d | 2019-07-31 | 2020-05-07 |  | 535d |  |  |  | 224h | 24,000 | LBNL |  |  |  | LBNL |
| 93 | 1.3.3.1.5.1 | Shipping staves from CERN to LBNL, Batch #1 |  | 7d | 2019-07-31 | 2019-08-08 | 8 | 535d | 0d |  | STAFFPHYS_Institution_LBNL | 56h | 6,000 |  | .35 | .35 | .35 | LBNL |
| 94 | 1.3.3.1.5.2 | Shipping staves from CERN to LBNL, Batch #2 |  | 7d | 2019-10-30 | 2019-11-07 | 9 | 958d | 0d |  | STAFFPHYS_Institution_LBNL | 56h | 6,000 |  | .35 | .35 | .35 | LBNL |
| 95 | 1.3.3.1.5.3 | Shipping staves from CERN to LBNL, Batch #3 |  | 7d | 2020-01-29 | 2020-02-06 | 10 | 893d | 0d |  | STAFFPHYS_Institution_LBNL | 56h | 6,000 |  | .35 | .35 | .35 | LBNL |
| 96 | 1.3.3.1.5.4 | Shipping staves from CERN to LBNL, Batch #4 |  | 7d | 2020-04-29 | 2020-05-07 | 11 | 828d | 0d |  | STAFFPHYS_Institution_LBNL | 56h | 6,000 |  | .35 | .35 | .35 | LBNL |
| 97 | 1.3.3.2 | **Carbon Structures** |  | 1000d | 2019-04-01 | 2023-01-27 |  | 130d |  |  |  | 4918.56h | 1,290,924.02 | LBNL |  |  |  |  |
| 98 | 1.3.3.2.1 | **Mechanics Detector Design** |  | 80d | 2019-04-01 | 2019-07-19 |  | 417d |  |  |  | 1792h | 348,723.2 | LANL |  |  |  |  |
| 99 | 1.3.3.2.1.1 | Develop MAPS inner tracker mechanical model |  | 4mo | 2019-04-01 | 2019-07-19 | 23 | 417d | 0d |  | PROF4_institution_LANL; PROF4_Institution_MIT; TECH4_Institution_MIT [80%] | 1792h | 348,723.2 |  | .35 | .35 | .35 |  |
| 100 | 1.3.3.2.2 | **End Wheels** |  | 145d | 2019-07-22 | 2020-02-07 |  | 417d |  |  |  | 1316h | 349,166.85 |  |  |  |  |  |
| 101 | 1.3.3.2.2.1 | Tooling Design |  | 1.75mo | 2019-07-22 | 2019-09-06 | 99 | 417d | 0d |  | PROF4_institution_LANL | 280h | 85,534.4 |  | .45 | .45 | .45 |  |
| 102 | 1.3.3.2.2.2 | Tooling material |  | 30d | 2019-09-09 | 2019-10-18 | 101 | 417d | 0d |  | TECH4_Institution_LANL [5%] | 12h | 62,332.45 |  | .45 | .45 | .45 |  |
| 103 | 1.3.3.2.2.3 | Tooling assembly |  | 30d | 2019-10-21 | 2019-11-29 | 23, 102, 101 | 417d | 0d |  | MECHTECH4_Institution_LBNL | 240h | 32,880 | LBNL | .45 | .45 | .45 |  |
| 104 | 1.3.3.2.2.4 | Material |  | 2d | 2019-12-02 | 2019-12-03 | 103 | 417d | 0d |  | PROF4_institution_LANL | 16h | 20,964 |  | .45 | .45 | .45 |  |
| 105 | 1.3.3.2.2.5 | Production and Test |  | 48d | 2019-12-04 | 2020-02-07 | 104 | 417d | 0d | start no earlier than 2018-08-08 | MECHTECH4_Institution_LBNL; MECHENG4_Institution_LBNL | 768h | 147,456 | LBNL | .45 | .45 | .45 |  |
| 106 | 1.3.3.2.3 | **Mechanics Fabrication** |  | 1000d | 2019-04-01 | 2023-01-27 |  | 130d |  |  |  | 1586.56h | 529,177.97 |  |  |  |  |  |
| 107 | 1.3.3.2.3.1 | Travel LBNL |  | 1000d | 2019-04-01 | 2023-01-27 | 23 | 130d |  | start no earlier than 2017-11-01 |  |  | 70,000 |  | .35 | .35 | .35 |  |
| 108 | 1.3.3.2.3.2 | **CYSS Cylindrical Structure** |  | 98d | 2019-07-22 | 2019-12-04 | 99 | 604d |  |  |  | 849.92h | 215,911.43 | LBNL |  |  |  |  |
| 109 | 1.3.3.2.3.2.1 | tooling design |  | 1.2mo | 2019-07-22 | 2019-08-22 |  | 604d | 0d |  | PROF4_institution_LANL | 192h | 58,652.16 |  | .45 | .45 | .45 |  |
| 110 | 1.3.3.2.3.2.2 | tooling material |  | 15d | 2019-08-23 | 2019-09-12 | 109 | 604d | 0d |  | STAFFPHYS_Institution_LBNL | 120h | 30,000 |  | .45 | .45 | .45 |  |
| 111 | 1.3.3.2.3.2.3 | tooling iteration |  | 15d | 2019-09-13 | 2019-10-03 | 110 | 604d | 0d |  | STAFFPHYS_Institution_LBNL [20%] | 24h | 30,000 |  | .45 | .45 | .45 |  |
| 112 | 1.3.3.2.3.2.4 | Procure CYSS Material |  | 5d | 2019-10-04 | 2019-10-10 | 111 | 604d | 0d |  | STAFFPHYS_Institution_LBNL [20%] | 8h | 15,940 | LBNL | .45 | .45 | .45 |  |
| 113 | 1.3.3.2.3.2.5 | Tolling Assembly |  | 15d | 2019-10-11 | 2019-10-31 | 112 | 604d | 0d |  | MECHTECH4_Institution_LBNL | 120h | 16,440 |  | .45 | .45 | .45 |  |
| 114 | 1.3.3.2.3.2.6 | Production & Test CYSS |  | 24d | 2019-11-01 | 2019-12-04 | 113 | 604d | 0d |  | MECHENG4_Institution_LBNL [88%]; STAFFPHYS_Institution_LBNL [25%]; MECHTECH4_Institution_LBNL | 385.92h | 64,879.27 | LBNL | .45 | .45 | .45 |  |
| 115 | 1.3.3.2.3.2.7 | Milestone: Complete CYSS | milestone | 0d | 2019-12-04 | 2019-12-04 | 114 | 604d | 187d |  |  |  |  | LBNL |  |  |  |  |

Notes:
- 87: From ITS
- 88: From ITS
- 92: ·7-day round trip for each shipment. / ·$5k for a seat for the courier and another seat for the shipping box (Cello in the plane). / ·$1k for hotel + per diem / ·4 trips total
- 105: from Luciano/Dave estimates
- 110: similar review for OB
- 112: 50% OB-CYSS material
- 114: ~66% OB-COSS

| ID | WBS | Task | Type | Duration | Start | Finish | Predecessors | Total slack | Free slack | Constraint | Resources | Work | Cost | Institution | Material contingency | Labor Contingency | Total Contingency |
| --- | --- | --- | --- | --- | --- | --- | --- | --- | --- | --- | --- | --- | --- | --- | --- | --- | --- |
| 116 | 1.3.3.2.3.3 | **Service Barrel (SB)** |  | 80d | 2019-09-13 | 2020-01-02 |  | 702d |  |  |  | 736.64h | 243,266.54 | LBNL |  |  |  |
| 117 | 1.3.3.2.3.3.1 | Review SB Design-Fabrication Compatibility |  | 40d | 2019-09-13 | 2019-11-07 | 99, 23, 110 | 971d |  |  | MECHENG4_Institution_LBNL [16%]; STAFFPHYS_Institution_LBNL [50%]; POSTD_Institution_LBNL [50%] | 91.2h | 12,492.8 |  | .30 | .30 | .30 |
| 118 | 1.3.3.2.3.3.2 | Hold SB Review (PRR) |  | 15d | 2019-09-13 | 2019-10-03 | 110 | 702d | 0d |  | MECHENG4_Institution_LBNL [20%]; STAFFPHYS_Institution_LBNL [20%]; POSTD_Institution_LBNL [20%]; PROF4_Institution_MIT [33%] | 111.6h | 12,230.4 |  | .30 | .30 | .30 |
| 119 | 1.3.3.2.3.3.3 | Tooling |  | 20d | 2019-10-04 | 2019-10-31 | 118 | 702d | 0d |  | MECHTECH4_Institution_LBNL [50%]; MECHENG4_Institution_LBNL | 240h | 90,480 |  | .2 | .2 | .2 |
| 120 | 1.3.3.2.3.3.4 | Procure SB Material |  | 5d | 2019-11-01 | 2019-11-07 | 119 | 702d | 19d | start no earlier than 2005-04-01 | STAFFPHYS_Institution_LBNL [20%] | 8h | 75,940 | LBNL | .30 | .30 | .30 |
| 121 | 1.3.3.2.3.3.5 | Production & Test SB |  | 21d | 2019-12-05 | 2020-01-02 | 120, 114, 126 | 683d | 0d |  | MECHENG4_Institution_LBNL [67%]; MECHTECH4_Institution_LBNL | 285.84h | 52,123.34 | LBNL | .30 | .30 | .30 |
| 122 | 1.3.3.2.3.3.6 | Milestone: Complete SB | milestone | 0d | 2020-01-02 | 2020-01-02 | 121 | 683d | 246d |  |  |  |  | LBNL |  |  |  |
| 123 | 1.3.3.2.4 | **MVTX Final Design Review** |  | 12d | 2019-10-04 | 2019-10-21 |  | 715d |  |  |  | 224h | 63,856 |  |  |  |  |
| 124 | 1.3.3.2.4.1 | MVTX Design Review |  | 2d | 2019-10-04 | 2019-10-07 | 118, 99, 110 | 715d | 0d |  | MECHENG4_Institution_LBNL; STAFFPHYS_Institution_LBNL; PROF4_institution_LANL; SCI3_Institution_LANL | 64h | 18,976 | ALL | .1 | .1 | .1 |
| 125 | 1.3.3.2.4.2 | Incorporate review comments |  | 9d | 2019-10-08 | 2019-10-18 | 124 | 715d | 0d |  | MECHENG4_Institution_LBNL; PROF4_institution_LANL | 144h | 40,392 | ALL | .10 | .10 | .10 |
| 126 | 1.3.3.2.4.3 | Complete Final Design |  | 1d | 2019-10-21 | 2019-10-21 | 125 | 715d | 0d |  | MECHENG4_Institution_LBNL; PROF4_institution_LANL | 16h | 4,488 | ALL | .10 | .10 | .10 |
| 127 | 1.3.3.3 | **Barrel Assembly** |  | 386d | 2019-08-09 | 2021-01-29 |  | 535d |  |  |  | 7254.48h | 222,590.48 |  |  |  |  |
| 128 | 1.3.3.3.1 | **Assembly and Testing** |  | 386d | 2019-08-09 | 2021-01-29 |  | 535d |  |  |  | 7254.48h | 222,590.48 |  |  |  |  |
| 129 | 1.3.3.3.1.1 | Receive 1st batch Staves from CERN |  | 1d | 2019-08-09 | 2019-08-09 | 93 | 535d | 0d |  |  |  |  | LBNL |  |  |  |
| 130 | 1.3.3.3.1.2 | Test and Rework 1st batch Staves |  | 12d | 2019-08-12 | 2019-08-27 | 129 | 535d | 118d |  | ELENG3_Institution_LBNL [10%]; MECHENG3_Institution_LBNL [8%]; ELTECH4_Institution_LBNL [20%]; POSTD_Institution_LBNL; STAFFPHYS_Institution_LBNL [50%]; GRSTUD_Institution_LBNL | 276.48h | 5,239.68 | LBNL | .30 | .30 | .30 |
| 131 | 1.3.3.3.1.3 | Receive 2nd batch Staves from CERN |  | 1d | 2019-11-08 | 2019-11-08 | 94 | 958d | 0d |  |  |  |  |  | .3 | .3 | .3 |
| 132 | 1.3.3.3.1.4 | Test and Rework 2nd batch Staves |  | 12d | 2019-11-11 | 2019-11-26 | 131 | 958d |  |  |  |  |  |  | .3 | .3 | .3 |
| 133 | 1.3.3.3.1.5 | Receive 3rd batch Staves from CERN |  | 1d | 2020-02-07 | 2020-02-07 | 95 | 893d | 0d |  |  |  |  |  | .3 | .3 | .3 |
| 134 | 1.3.3.3.1.6 | Test and Rework 3rd batch Staves |  | 12d | 2020-02-10 | 2020-02-25 | 133 | 893d |  |  |  |  |  |  | .3 | .3 | .3 |
| 135 | 1.3.3.3.1.7 | Receive 4th batch Staves from CERN |  | 1d | 2020-05-08 | 2020-05-08 | 96 | 828d | 0d |  |  |  |  |  | .3 | .3 | .3 |
| 136 | 1.3.3.3.1.8 | Test and Rework 4th batch Staves |  | 12d | 2020-05-11 | 2020-05-26 | 135 | 828d |  |  |  |  |  |  | .3 | .3 | .3 |
| 137 | 1.3.3.3.1.9 | **Layer Assembly and Test** |  | 140d | 2020-02-10 | 2020-08-21 |  | 417d |  |  |  | 2885.2h | 74,006.4 | LBNL |  |  |  |
| 138 | 1.3.3.3.1.9.1 | Test Installation of Staves onto Layer End-Wheels |  | 20d | 2020-02-10 | 2020-03-06 | 130, 105 | 417d | 0d |  | MECHENG3_Institution_LBNL [10%]; MECHTECH4_Institution_LBNL [20%]; POSTD_Institution_LBNL; STAFFPHYS_Institution_LBNL | 368h | 7,056 | LBNL | .35 | .35 | .35 |
| 139 | 1.3.3.3.1.9.2 | Hold Half-Detector Assembly Review (PRR) |  | 5d | 2020-03-09 | 2020-03-13 | 138 | 417d | 0d |  | MECHENG3_Institution_LBNL [40%]; POSTD_Institution_LBNL; STAFFPHYS_Institution_LBNL | 96h | 2,672 | LBNL | .20 | .20 | .20 |
| 140 | 1.3.3.3.1.9.3 | Install Staves Onto Layer End-Wheels To Form Layers |  | 70d | 2020-03-16 | 2020-06-19 | 139, 130 | 417d | 0d |  | MECHENG3_Institution_LBNL [10%]; ELENG3_Institution_LBNL [10%]; POSTD_Institution_LBNL; STAFFPHYS_Institution_LBNL [25%]; ELTECH4_Institution_LBNL [20%]; GRSTUD_Institution_LBNL | 1484h | 36,416 | LBNL | .40 | .40 | .40 |
| 141 | 1.3.3.3.1.9.4 | Test and Rework Layers After Assembly |  | 30d | 2020-06-22 | 2020-07-31 | 140 | 417d | 0d |  | ELENG3_Institution_LBNL [10%]; MECHENG3_Institution_LBNL [17%]; ELTECH4_Institution_LBNL [10%]; POSTD_Institution_LBNL; STAFFPHYS_Institution_LBNL [33%]; GRSTUD_Institution_LBNL | 648h | 16,853.6 | LBNL | .35 | .35 | .35 |
| 142 | 1.3.3.3.1.9.5 | Perform Half-Detector Metrology On Layers |  | 15d | 2020-08-03 | 2020-08-21 | 141 | 417d | 0d |  | CMMTECH4_Institution_LBNL [66%]; STAFFPHYS_Institution_LBNL [25%]; POSTD_Institution_LBNL; GRSTUD_Institution_LBNL [50%] | 289.2h | 11,008.8 | LBNL | .35 | .35 | .35 |
| 143 | 1.3.3.3.1.9.6 | Milestone: Complete Layers | milestone | 0d | 2020-08-21 | 2020-08-21 | 142 | 417d | 0d |  |  |  |  | LBNL |  |  |  |

Notes:
- 117: assuming design is final and we are just reviewing compatibility
- 118: similar review for OB
- 120: ~90% OB-COSS material
- 121: ~ OB-CYSS, from Luciano's estimates and CYSS dimensions
- 130: From ITS estimates, scaled to the number of staves
- 138: From previous projects and ITS OB model
- 140: From previous projects and ITS OB model
- 141: From ITS estimates, scaled to the number of staves
- 142: From previous estimates and ITS OB model

| ID | WBS | Task | Type | Duration | Start | Finish | Predecessors | Total slack | Free slack | Constraint | Resources | Work | Cost | Institution | Material contingency | Labor Contingency | Total Contingency | Text1 |
| --- | --- | --- | --- | --- | --- | --- | --- | --- | --- | --- | --- | --- | --- | --- | --- | --- | --- | --- |
| 144 | 1.3.3.3.1.10 | **Half Barrel #1 Assembly and Test** |  | 95d | 2020-08-24 | 2021-01-01 |  | 417d |  |  |  | 2046.4h | 71,399.4 | LBNL |  |  |  |  |
| 145 | 1.3.3.3.1.10.1 | Assemble Layers and CYSS Into Half-Detector |  | 20d | 2020-08-24 | 2020-09-18 | 143, 115 | 417d | 0d |  | ELENG3_Institution_LBNL [10%]; MECHENG3_Institution_LBNL [25%]; ELTECH4_Institution_LBNL [20%]; POSTD_Institution_LBNL; STAFFPHYS_Institution_LBNL [50%]; GRSTUD_Institution_LBNL [50%] | 408h | 16,384 | LBNL | .40 | .40 | .40 |  |
| 146 | 1.3.3.3.1.10.2 | Test and Rework Half-Detector |  | 30d | 2020-09-21 | 2020-10-30 | 145 | 595d | 0d |  | ELENG3_Institution_LBNL [10%]; MECHENG3_Institution_LBNL [20%]; ELTECH4_Institution_LBNL [20%]; POSTD_Institution_LBNL; STAFFPHYS_Institution_LBNL [33%]; GRSTUD_Institution_LBNL | 679.2h | 21,571.2 | LBNL | .35 | .35 | .35 |  |
| 147 | 1.3.3.3.1.10.3 | Perform Half-Detector Metrology On Final Assembly |  | 10d | 2020-11-02 | 2020-11-13 | 146 | 595d | 0d |  | CMMTECH4_Institution_LBNL [70%]; STAFFPHYS_Institution_LBNL [50%]; POSTD_Institution_LBNL; GRSTUD_Institution_LBNL [50%] | 216h | 8,120 | LBNL | .35 | .35 | .35 |  |
| 148 | 1.3.3.3.1.10.4 | Validation Of Final Assembly |  | 20d | 2020-11-16 | 2020-12-11 | 147 | 595d | 0d |  | ELENG3_Institution_LBNL [10%]; MECHENG3_Institution_LBNL [10%]; CMMTECH4_Institution_LBNL [15%]; POSTD_Institution_LBNL; STAFFPHYS_Institution_LBNL; MECHTECH4_Institution_LBNL [20%]; GRSTUD_Institution_LBNL | 568h | 16,552 | LBNL | .35 | .35 | .35 |  |
| 149 | 1.3.3.3.1.10.5 | Pack/Ship Final Assemblies To BNL |  | 15d | 2020-12-14 | 2021-01-01 | 148, 122 | 595d | 0d |  | MECHENG3_Institution_LBNL [13%]; MECHTECH4_Institution_LBNL [13%]; POSTD_Institution_LBNL; STAFFPHYS_Institution_LBNL [20%] | 175.2h | 8,772.2 | LBNL | .35 | .35 | .35 |  |
| 150 | 1.3.3.3.1.11 | **Half Barrel #2 Assembly and Test** |  | 95d | 2020-09-21 | 2021-01-29 |  | 417d |  |  |  | 2046.4h | 71,945 | LBNL |  |  |  |  |
| 151 | 1.3.3.3.1.11.1 | Assemble Layers and CYSS Into Half-Detector |  | 20d | 2020-09-21 | 2020-10-16 | 143, 145, 115 | 417d | 0d |  | ELENG3_Institution_LBNL [10%]; MECHENG3_Institution_LBNL [25%]; ELTECH4_Institution_LBNL [20%]; POSTD_Institution_LBNL; STAFFPHYS_Institution_LBNL [50%]; GRSTUD_Institution_LBNL [50%] | 408h | 16,724.8 | LBNL | .40 | .40 | .40 |  |
| 152 | 1.3.3.3.1.11.2 | Test and Rework Half-Detector |  | 30d | 2020-10-19 | 2020-11-27 | 151 | 417d | 0d |  | ELENG3_Institution_LBNL [10%]; MECHENG3_Institution_LBNL [20%]; ELTECH4_Institution_LBNL [20%]; POSTD_Institution_LBNL; STAFFPHYS_Institution_LBNL [33%]; GRSTUD_Institution_LBNL | 679.2h | 21,776 | LBNL | .35 | .35 | .35 |  |
| 153 | 1.3.3.3.1.11.3 | Perform Half-Detector Metrology On Final Assembly |  | 10d | 2020-11-30 | 2020-12-11 | 152 | 417d | 0d |  | CMMTECH4_Institution_LBNL [70%]; STAFFPHYS_Institution_LBNL [50%]; POSTD_Institution_LBNL; GRSTUD_Institution_LBNL [50%] | 216h | 8,120 | LBNL | .35 | .35 | .35 |  |
| 154 | 1.3.3.3.1.11.4 | Validation Of Final Assembly |  | 20d | 2020-12-14 | 2021-01-08 | 153 | 417d | 0d |  | ELENG3_Institution_LBNL [10%]; MECHENG3_Institution_LBNL [10%]; CMMTECH4_Institution_LBNL [15%]; POSTD_Institution_LBNL; STAFFPHYS_Institution_LBNL; MECHTECH4_Institution_LBNL [20%]; GRSTUD_Institution_LBNL | 568h | 16,552 | LBNL | .35 | .35 | .35 |  |
| 155 | 1.3.3.3.1.11.5 | Pack/Ship Final Assemblies To BNL |  | 15d | 2021-01-11 | 2021-01-29 | 154, 122 | 417d | 0d |  | MECHENG3_Institution_LBNL [13%]; MECHTECH4_Institution_LBNL [13%]; POSTD_Institution_LBNL; STAFFPHYS_Institution_LBNL [20%] | 175.2h | 8,772.2 | LBNL | .35 | .35 | .35 |  |
| 156 | 1.3.3.3.1.11.6 | Milestone: Complete Barrel (RR) | milestone | 0d | 2021-01-29 | 2021-01-29 | 155 | 650d |  | start no earlier than 2016-10-03 |  |  |  | LBNL |  |  |  |  |
| 157 | 1.3.4 | **Integration and Infrastructure** |  | 1000d | 2019-04-01 | 2023-01-27 |  | 130d |  |  |  | 6780.8h | 970,792.68 |  |  |  |  |  |
| 158 | 1.3.4.1 | Clean Tent/Room |  | 100d | 2019-04-01 | 2019-08-16 | 23 | 1030d |  | start no earlier than 2016-10-03 |  |  | 50,000 |  | .35 | .35 | .35 |  |
| 159 | 1.3.4.2 | **Cooling System** |  | 1000d | 2019-04-01 | 2023-01-27 |  | 130d |  |  |  | 331.6h | 129,238.8 | MIT |  |  |  |  |
| 160 | 1.3.4.2.1 | travel |  | 1000d | 2019-04-01 | 2023-01-27 | 23 | 130d |  |  |  |  | 25,000 |  | .35 | .35 | .35 |  |
| 161 | 1.3.4.2.2 | Design (modify ALICE) |  | 1mo | 2019-10-22 | 2019-11-18 | 126 | 769d | 0d |  | PROF4_Institution_MIT; TECH4_Institution_MIT [50%] | 160h | 21,304 |  | .35 | .35 | .35 |  |
| 162 | 1.3.4.2.3 | Mock up Testing |  | 3w | 2019-11-19 | 2019-12-09 | 161 | 769d | 0d |  | TECH4_Institution_MIT; PROF4_Institution_MIT [33%] | 99.6h | 32,550.8 |  | .35 | .35 | .35 |  |
| 163 | 1.3.4.2.4 | Final Design of Cooling System |  | 5d | 2019-12-10 | 2019-12-16 | 162 | 769d | 0d |  | PROF4_Institution_MIT | 40h | 6,720 |  | .35 | .35 | .35 |  |
| 164 | 1.3.4.2.5 | Procure Cooling Plant |  | 100d | 2021-10-01 | 2022-02-17 | 163 | 301d | 0d | start no earlier than 2021-10-01 | SCI3_Institution_MIT [2%]; TECH4_Institution_MIT [2%] | 32h | 41,664 | MIT | .35 | .35 | .35 | DOE |
| 165 | 1.3.4.2.6 | Ship to BNL |  | 1w | 2022-02-18 | 2022-02-24 | 164 | 301d | 0d |  |  |  | 2,000 |  | .35 | .35 | .35 |  |
| 166 | 1.3.4.3 | **Safety Systems** |  | 724d | 2019-04-01 | 2022-01-06 |  | 406d |  |  |  | 986.4h | 133,995.2 | MIT |  |  |  |  |
| 167 | 1.3.4.3.1 | travel |  | 700d | 2019-04-01 | 2021-12-03 | 23 | 430d |  |  |  |  | 25,000 |  | .35 | .35 | .35 |  |
| 168 | 1.3.4.3.2 | Define MVTX Safety and Interlock requirements |  | 2w | 2019-12-17 | 2019-12-30 | 163, 126 | 798.29d | 0d |  | STAFFPHYS_Institution_LBNL [50%]; POSTD_Institution_LBNL [50%]; PROF4_Institution_MIT [50%] | 120h | 6,720 | LBNL | .35 | .35 | .35 |  |
| 169 | 1.3.4.3.3 | review sensors & interlocks with BNL ES&H |  | 10d | 2019-12-31 | 2020-01-13 | 168 | 798.29d | 0d |  | PROF4_Institution_MIT [50%]; STAFFPHYS_Institution_LBNL [50%] | 80h | 6,720 | LBNL | .15 | .15 | .15 |  |
| 170 | 1.3.4.3.4 | Design electronics safety system |  | 5.14w | 2020-01-14 | 2020-02-18 | 169 | 798.29d | 0d |  | STAFFPHYS_Institution_LBNL [50%]; POSTD_Institution_LBNL [50%]; PROF4_Institution_MIT [40%] | 288h | 13,824 | MIT | .35 | .35 | .35 |  |
| 171 | 1.3.4.3.5 | cooling interlocks design |  | 30d | 2020-02-18 | 2020-03-31 | 170 | 798.29d | 392.29d |  | PROF4_Institution_MIT [50%] | 120h | 20,160 | MIT | .35 | .35 | .35 |  |
| 172 | 1.3.4.3.6 | Procure Safety Systems |  | 8w | 2021-10-01 | 2021-11-25 | 171 | 406d | 0d | start no earlier than 2021-10-01 | TECH4_Institution_MIT [5%]; PROF4_Institution_MIT [13%] | 57.6h | 19,068.8 | MIT | .35 | .35 | .35 |  |
| 173 | 1.3.4.3.7 | System test at MIT |  | 3w | 2021-11-26 | 2021-12-16 | 172 | 406d | 0d |  | TECH4_Institution_MIT; PROF4_Institution_MIT [34%] | 160.8h | 19,742.4 |  | .35 | .35 | .35 |  |
| 174 | 1.3.4.3.8 | Ship to BNL |  | 1w | 2021-12-17 | 2021-12-23 | 173 | 406d | 0d |  |  |  | 200 |  | .35 | .35 | .35 |  |
| 175 | 1.3.4.3.9 | Test at BNL |  | 2w | 2021-12-24 | 2022-01-06 | 174 | 406d |  |  | TECH4_Institution_MIT; PROF4_Institution_MIT | 160h | 22,560 |  | .35 | .35 | .35 |  |

Notes:
- 145: Scaled from previous project
- 146: Scaled from previous project
- 147: Scaled from previous project
- 148: Scaled from previous project
- 149: Scaled from previous project
- 151: Scaled from previous project
- 152: Scaled from previous project
- 153: Scaled from previous project
- 154: Scaled from previous project
- 155: Scaled from previous project
- 157: critical to have early R&D fund to finish mechanics for CD-2/CD3
- 166: monitoring temp, flow rates, I, V etc.

| ID | WBS | Task | Type | Duration | Start | Finish | Predecessors | Total slack | Free slack | Constraint | Resources | Work | Cost | Institution | Material contingency | Labor Contingency | Total Contingency | Text1 |
| --- | --- | --- | --- | --- | --- | --- | --- | --- | --- | --- | --- | --- | --- | --- | --- | --- | --- | --- |
| 176 | 1.3.4.4 | **Stave Support Frame & MVTX Interface to sPHENIX** |  | 1000d | 2019-04-01 | 2023-01-27 |  | 130d |  |  |  | 1614.8h | 432,254.84 | LANL |  |  |  |  |
| 177 | 1.3.4.4.1 | travel |  | 1000d | 2019-04-01 | 2023-01-27 |  | 130d |  | start no earlier than 2018-10-08 |  |  | 20,000 |  | .1 | .1 | .1 |  |
| 178 | 1.3.4.4.2 | Design Interface to sPHENIX |  | 100d | 2019-10-07 | 2020-02-21 |  | 795d | 0d | start no earlier than 2019-10-05 | PROF4_Institution_MIT | 800h | 134,400 | MIT | .50 | .50 | .50 |  |
| 179 | 1.3.4.4.3 | FEA,Thermal,stress analysis |  | 50d | 2020-05-04 | 2020-07-10 | 99, 180 | 795d |  |  | PROF4_Institution_MIT | 400h | 67,200 | MIT | .50 | .50 | .50 |  |
| 180 | 1.3.4.4.4 | design iinsertion system |  | 10w | 2020-02-24 | 2020-05-01 | 126, 178 | 795d | 0d |  | PROF4_Institution_MIT | 400h | 67,200 |  | .50 | .50 | .50 |  |
| 181 | 1.3.4.4.5 | procure support structure |  | 8w | 2020-02-24 | 2020-04-17 | 178 | 855d |  |  | TECH4_Institution_MIT [2%] | 6.4h | 100,629.12 |  | .50 | .50 | .50 |  |
| 182 | 1.3.4.4.6 | Procure insertion system |  | 8w | 2020-05-04 | 2020-06-26 | 180 | 804.5d | 0d |  | TECH4_Institution_MIT [2%] | 6.4h | 40,629.12 |  | .50 | .50 | .50 |  |
| 183 | 1.3.4.4.7 | ship to BNL |  | 0.1w | 2020-06-29 | 2020-06-29 | 182 | 804.5d |  |  | TECH4_Institution_MIT [50%] | 2h | 2,196.6 |  | .35 | .35 | .35 |  |
| 184 | 1.3.4.5 | **Half detector Assembly Readout and Cooling Test at BNL** |  | 781.34d | 2019-06-05 | 2022-06-02 |  | 301d |  |  |  | 1176h | 56,495.84 |  |  |  |  |  |
| 185 | 1.3.4.5.1 | Test Half Barrel #1 |  | 15d | 2021-01-04 | 2021-01-22 | 149 | 595d | 294d |  | MECHENG4_Institution_LBNL [20%]; POSTD_Institution_LBNL; STAFFPHYS_Institution_LBNL [20%] | 168h | 6,144 | LBNL | .35 | .35 | .35 |  |
| 186 | 1.3.4.5.2 | Test Half Barrel #2 |  | 15d | 2021-02-01 | 2021-02-19 | 155 | 417d | 0d |  | MECHENG4_Institution_LBNL [20%]; POSTD_Institution_LBNL; STAFFPHYS_Institution_LBNL [20%] | 168h | 6,144 | LBNL | .35 | .35 | .35 |  |
| 187 | 1.3.4.5.3 | Assemble & Test Cooling System at BNL |  | 10d | 2022-02-25 | 2022-03-10 | 165 | 301d | 0d |  | TECH4_Institution_MIT; SCI3_Institution_MIT [50%]; PROF4_Institution_MIT | 160h | 15,440 | MIT | .35 | .35 | .35 |  |
| 188 | 1.3.4.5.4 | Complete System Test at BNL |  | 3mo | 2022-03-11 | 2022-06-02 | 185, 186, 187 | 301d |  |  | SCI3_Institution_LANL | 480h |  |  |  |  |  |  |
| 189 | 1.3.4.5.5 | test RU at BNL |  | 0.8w | 2019-09-30 | 2019-10-03 | 42 | 996d |  |  | SCI3_Institution_LANL; PROF4_institution_LANL; Electrical Engineer UTAustin [50%] | 80h | 12,539.84 | LANL | .35 | .35 | .35 |  |
| 190 | 1.3.4.5.6 | test FELIX at BNL |  | 0.8w | 2020-07-08 | 2020-07-14 | 51 | 793.67d |  |  | SCI3_Institution_LANL; PROF4_institution_LANL; Electrical Engineer UTAustin [50%] | 80h | 12,608 | LANL | .35 | .35 | .35 |  |
| 191 | 1.3.4.5.7 | PS tests at BNL |  | 0.5w | 2019-06-05 | 2019-06-10 | 69 | 1079.84d |  |  | POSTD_Institution_LBNL; ELENG3_Institution_LBNL | 40h | 3,620 | LBNL | .35 | .35 | .35 |  |
| 192 | 1.3.4.6 | **Installation and Commissioning** |  | 484d | 2021-02-22 | 2022-12-29 |  | 151d |  |  |  | 2672h | 168,808 |  |  |  |  |  |
| 193 | 1.3.4.6.1 | Installation Prep |  | 10d | 2021-02-22 | 2021-03-05 | 186 | 417d | 0d | start no earlier than 2016-10-03 | Mech Tech; Physicist; Elec tech; STAFFPHYS_Institution_LBNL; POSTD_Institution_LBNL | 400h | 15,520 | ALL | .35 | .35 | .35 | DOE |
| 194 | 1.3.4.6.2 | Installation Review |  | 1d | 2021-03-08 | 2021-03-08 | 193 | 417d | 0d |  | Physicist; Mechanical Engineer; Electrical Engineer UTAustin; STAFFPHYS_Institution_LBNL; POSTD_Institution_LBNL | 40h | 2,320 | ALL | .10 | .10 | .10 | DOE |
| 195 | 1.3.4.6.3 | Install FELIX |  | 2d | 2021-03-09 | 2021-03-10 | 194 | 417d | 0d |  | SCI3_Institution_LANL; PROF4_institution_LANL | 32h | 5,168 |  | .35 | .35 | .35 |  |
| 196 | 1.3.4.6.4 | Install Optical fibers |  | 1w | 2021-03-11 | 2021-03-17 | 195 | 417d | 0d |  | TECH4_Institution_LANL | 40h | 8,120 |  | .35 | .35 | .35 |  |
| 197 | 1.3.4.6.5 | Install RU |  | 1w | 2021-03-18 | 2021-03-24 | 196 | 417d | 0d |  | SCI3_Institution_LANL; PROF4_institution_LANL; Electrical Engineer UTAustin | 120h | 19,320 |  | .35 | .35 | .35 |  |
| 198 | 1.3.4.6.6 | Install Samtec Cables |  | 1w | 2021-03-25 | 2021-03-31 | 197 | 417d | 0d |  | TECH4_Institution_LANL | 40h | 8,120 |  | .35 | .35 | .35 |  |
| 199 | 1.3.4.6.7 | Electronics Integration (sPHENIX FELIX support) |  | 3mo | 2021-04-01 | 2021-06-23 | 198 | 417d | 266d |  | Physicist [50%]; SCI3_Institution_LANL [50%] | 480h |  |  | .3 | .3 | .3 |  |
| 200 | 1.3.4.6.8 | Install Half-Barrel 1 |  | 1mo | 2022-07-01 | 2022-07-28 | 194, 20, 199 | 151d | 0d |  | MECHTECH4_Institution_LBNL [50%]; STAFFPHYS_Institution_LBNL; MECHENG3_Institution_LBNL [50%]; POSTD_Institution_LBNL | 220h | 26,320 |  | .35 | .35 | .35 |  |
| 201 | 1.3.4.6.9 | Install Half-Barrel 2 |  | 1mo | 2022-07-29 | 2022-08-25 | 198, 200 | 151d | 0d |  | MECHTECH4_Institution_LBNL [50%]; STAFFPHYS_Institution_LBNL; MECHENG3_Institution_LBNL [50%]; POSTD_Institution_LBNL | 220h | 26,320 |  | .35 | .35 | .35 |  |
| 202 | 1.3.4.6.10 | Commissioning |  | 90d | 2022-08-26 | 2022-12-29 | 201 | 151d | 0d |  | Physicist [200%]; Electrical Engineer UTAustin [50%] | 1080h | 57,600 |  |  |  |  |  |
| 203 | 1.3.5 | Ready for beam | milestone | 0d | 2022-12-29 | 2022-12-29 | 202 | 151d |  |  |  |  |  |  |  |  |  |  |

Notes:
- 192: installatino by 6/2021
